# JRA3-T1 WI 1.2 - Activity plan

Schedule from MS Project, 2014-01-06 to 2015-05-28, status date 2013-12-06, A marks actual dates.
HP

## Calendars

- Standard: Mon-Fri 09:00-13:00, 14:00-18:00; Sat-Sun off.

## Schedule

| ID | WBS | Task | Type | Duration | Start | Finish | Predecessors | Complete | Remaining | Total slack | Free slack |
| --- | --- | --- | --- | --- | --- | --- | --- | --- | --- | --- | --- |
| 1 | 1 | **Documentation phase** |  | 59d | 2014-01-06 A | 2014-03-27 |  | 90% | 5.96d | 37.5d | 0d |
| 2 | 1.1 | Documentation on Grouper |  | 59d | 2014-01-06 A | 2014-03-27 A |  | 100% |  |  |  |
| 3 | 1.2 | Documentation on CoManage (to externalize group management) |  | 17d | 2014-03-05 A | 2014-03-27 | 2FF | 40% | 10.2d | 26d |  |
| 4 | 1.3 | Documentation on Grouper integration with Shibboleth |  | 25d | 2014-02-21 A | 2014-03-27 A | 2FF | 100% |  |  |  |
| 5 | 2 | **Feasibility (14 month, by 30/05/2014)** |  | 35d | 2014-03-28 A | 2014-05-15 |  | 80% | 7d | 9.5d | 0d |
| 6 | 2.1 | Feasiblity report |  | 35d | 2014-03-28 A | 2014-05-15 | 1 | 80% | 7d | 9.5d | 0d |
| 7 | 2.2 | Feasibility milestone | milestone | 0d | 2014-05-15 | 2014-05-15 | 6 |  |  | 1.5d |  |
| 8 | 3 | **Design (18 month, by 30/09/1024)** |  | 80d | 2014-06-03 A | 2014-09-22 |  | 6% | 75.43d | 1.5d | 0d |
| 9 | 3.1 | Solution design and architecture definition |  | 80d | 2014-06-03 A | 2014-09-22 | 5FS+12d | 10% | 72d | 1.5d | 0d |
| 10 | 3.2 | Architecture for discovery |  | 60d | 2014-07-01 | 2014-09-22 | 9FF |  |  | 1.5d | 0d |
| 11 | 3.3 | Design milestone | milestone | 0d | 2014-09-22 | 2014-09-22 | 10 |  |  | 1.5d |  |
| 12 | 4 | **Build (21 month, by 31/12/2014)** |  | 64d | 2014-10-02 A | 2014-12-30 |  | 4% | 61.21d | 0d |  |
| 13 | 4.1 | Installation of a Grouper instance |  | 5d | 2014-10-02 | 2014-10-08 | 8FS+7d |  |  | 1.5d | 0d |
| 14 | 4.2 | Integration of Grouper with a Shibboleth IdP |  | 1d | 2014-10-09 | 2014-10-09 | 13 |  |  | 1.5d | 0d |
| 15 | 4.3 | Installation of CoManage |  | 5d | 2014-10-03 | 2014-10-09 | 13FF+8h |  |  | 1.5d | 0d |
| 16 | 4.4 | Configuration of Grouper as an Attribute Authority |  | 7d | 2014-10-10 | 2014-10-20 | 13, 14, 15 |  |  | 1.5d | 0d |
| 17 | 4.5 | **Integrate Grouper with a wiki SP** |  | 23d | 2014-10-21 | 2014-11-20 |  |  |  | 1.5d | 0d |
| 18 | 4.5.1 | Integration of Grouper with a Shibboleth SP |  | 2d | 2014-10-21 | 2014-10-22 | 16 |  |  | 1.5d | 0d |
| 19 | 4.5.2 | Modifications of the wiki application to manage Grouper groups |  | 21d | 2014-10-23 | 2014-11-20 | 18 |  |  | 1.5d |  |
| 20 | 4.6 | **Integrate Grouper with a moodle SP** |  | 17d | 2014-11-21 A | 2014-12-15 |  | 22% | 13.3d | 0d |  |
| 21 | 4.6.1 | Integration of Grouper with a Shibboleth SP |  | 1d | 2014-11-21 A | 2014-11-21 | 17 | 50% | 0.5d | 1d | 0d |
| 22 | 4.6.2 | Modifications of the moodle application to manage Grouper groups |  | 16d | 2014-11-24 A | 2014-12-15 | 21 | 20% | 12.8d | 0d |  |
| 23 | 4.7 | **Integrate Grouper with GARRbox SP** |  | 17d | 2014-11-24 | 2014-12-16 |  |  |  | 0d |  |
| 24 | 4.7.1 | Integration of Grouper with a Shibboleth SP |  | 1d | 2014-12-16 | 2014-12-16 | 20 |  |  | 0d |  |
| 25 | 4.7.2 | Modifications of the GARRbox application to manage Grouper groups |  | 16d | 2014-11-24 | 2014-12-15 | 21 |  |  | 1d |  |
| 26 | 4.8 | PoC documentation |  | 10d | 2014-12-17 | 2014-12-30 | 17, 20, 23 |  |  | 0d |  |
| 27 | 4.9 | Build milestone | milestone | 0d | 2014-12-30 | 2014-12-30 | 26 |  |  | 0d |  |

Notes:
- 1: Investigate which problem could be solved by Grouper and what can reasonably be done on groups and attribute within Identity Federation.
- 5: Investigate the need for a discovery protocol for groups and / or attribute provider.
- 6: Deliverable JRA3T1-321
- 8: Design an architecture for a group and/or attribute exchange mechanism for discovering external attributes and/or groups (COULD BE one track for attributes and another on
- 10: Deliverable JRA3T1-322
- 12: Build at least one PoC
- 26: Deliverable JRA3T1-323

| ID | WBS | Task | Type | Duration | Start | Finish | Predecessors | Total slack | Constraint |
| --- | --- | --- | --- | --- | --- | --- | --- | --- | --- |
| 28 | 5 | **Finalize (24 month, by 31/03/2015)** |  | 105d | 2015-01-02 | 2015-05-28 |  | 0d |  |
| 29 | 5.1 | Deliverables for dissemination |  | 30d | 2015-01-02 | 2015-02-12 | 12FS+2d | 0d |  |
| 30 | 5.2 | Disseminate information |  | 60d | 2015-02-13 | 2015-05-07 | 29 | 0d |  |
| 31 | 5.3 | Project closure milestone | milestone | 0d | 2015-05-28 | 2015-05-28 | 30FS+15d | 0d | start no earlier than 2014-01-07 |

Notes:
- 28: Disseminate information to the wider audience (in GN3+ / HE&R / world)
- 29: Deliverable JRA3T1-324
